# ODOT COMPLETION SCHEDULE PROGRAM V19.3

Schedule from MS Project, 2024-01-01 to 2025-05-15.
Oregon Dept of Transportation

## Calendars

- Standard: Mon-Fri 08:00-12:00, 13:00-17:00; Sat-Sun off. Exceptions (off unless hours are given): 2024-09-01 08:00-12:00, 13:00-17:00, 2025-02-01 08:00-12:00, 13:00-17:00.
- 7 DAY PER WEEK: Mon-Sun 08:00-12:00, 13:00-17:00.

## Schedule

| ID | WBS | Task | Type | Duration | Start | Finish | Predecessors | Total slack | Free slack | Constraint | Calendar |
| --- | --- | --- | --- | --- | --- | --- | --- | --- | --- | --- | --- |
| 1 | 1 | BID OPENING (KEY# 00000) | milestone | 0d | 2024-01-01 | 2024-01-01 |  | 393d | 0d | start no earlier than 2024-01-01 | 7 DAY PER WEEK |
| 2 | 2 | AWARD OF CONTRACT (00130.10) |  | 30d | 2024-01-01 | 2024-01-30 | 1 | 393d | 0d |  | 7 DAY PER WEEK |
| 3 | 3 | EXEC. OF CONTR. BY BIDDER (00130.50a) |  | 15d | 2024-01-31 | 2024-02-14 | 2 | 393d | 0d |  | 7 DAY PER WEEK |
| 4 | 4 | EXEC. OF CONTR. BY STATE (00130.50b) |  | 7d | 2024-02-15 | 2024-02-21 | 3 | 393d | 0d |  | 7 DAY PER WEEK |
| 5 | 5 | EXEC. OF NOTICE TO PROCEED (00130.90) |  | 5d | 2024-02-22 | 2024-02-26 | 4 | 393d | 0d |  | 7 DAY PER WEEK |
| 6 | 6 | NTP | milestone | 0d | 2024-02-26 | 2024-02-26 | 5 | 393d | 0d |  | 7 DAY PER WEEK |
| 7 | 7 | MOBILIZATION, PRECON |  | 20d | 2024-02-27 | 2024-03-25 | 6 | 300d |  |  |  |
| 8 | 8 | APPROVALS |  | 25d | 2024-02-27 | 2024-04-01 | 6 | 283d | 0d |  |  |
| 9 | 9 | TP & DT |  | 5d | 2024-04-02 | 2024-04-08 | 8 | 290d |  |  |  |
| 10 | 10 | EROSION CONTROL |  | 10d | 2024-04-02 | 2024-04-15 | 8 | 283d | 0d |  |  |
| 11 | 11 | IN WATER WORK PERMITS | milestone | 0d | 2024-04-01 | 2024-04-01 |  | 295d |  | finish no earlier than 2024-04-01 |  |
| 12 | 12 | PERMANENT SEEDING - WEST OF THE CASCADES - 01030.43(b) |  | 54d | 2024-03-01 | 2024-05-15 |  | 263d |  | finish no earlier than 2024-05-15 |  |
| 13 | 13 | PERMANENT SEEDING - WEST OF THE CASCADES - 01030.43(b) |  | 45d | 2024-09-01 | 2024-10-31 |  | 141d |  | finish no earlier than 2024-10-31 |  |
| 14 | 14 | PERMANENT SEEDING - EAST OF THE CASCADES - 01030.43(b) |  | 89d | 2024-10-02 | 2025-02-01 |  | 74d |  | finish no earlier than 2025-02-01 |  |
| 15 | 15 | PERMANENT SEEDING - WETLAND (STATEWIDE) - 01030.43(b) |  | 45d | 2024-09-01 | 2024-10-31 |  | 141d |  | finish no earlier than 2024-10-31 |  |
| 16 | 16 | PERMANENT SEEDING - WETLAND (STATEWIDE) - 01030.43(b) |  | 43d | 2024-03-01 | 2024-04-30 |  | 274d |  | finish no earlier than 2024-04-30 |  |
| 17 | 17 | PLANTING SEASON (WEST OF THE CASCADES) - (01040.41) |  | 185d | 2024-09-02 | 2025-05-15 |  | 0d |  | finish no earlier than 2025-05-15 |  |
| 18 | 18 | PLANTING SEASON (EAST OF THE CASCADES) - 01040.42 |  | 34d | 2024-10-15 | 2024-11-29 |  | 120d |  | start no earlier than 2024-10-15 |  |
| 19 | 19 | LEVEL 3 AND LEVEL 4 SEASONAL PAVING - (00744.40/00745.40) |  | 143d | 2024-03-15 | 2024-09-30 |  | 164d |  | finish no earlier than 2024-09-30 |  |
| 20 | 20 | MIGRATORY BIRD PROTECTION (00290.36)(a) |  | 132d? | 2024-03-01 | 2024-09-01 |  | 185d |  | finish no earlier than 2024-09-01 |  |
| 21 | 21 | **TEMPORARY FEATURES AND APPURTENANCES** |  | 0d | 2024-04-15 | 2024-04-15 |  | 283d |  |  |  |
| 22 | 21.1 | WORK ZONE TRAFFIC CONTROL | milestone | 0d | 2024-04-15 | 2024-04-15 | 10 | 283d | 0d |  |  |
| 23 | 21.2 | CONSTRUCT AND REMOVE DETOURS | milestone | 0d | 2024-04-15 | 2024-04-15 | 22 | 283d | 0d |  |  |
| 24 | 21.3 | TEMPORARY DRAINAGE FACILITIES | milestone | 0d | 2024-04-15 | 2024-04-15 | 23 | 283d | 0d |  |  |
| 25 | 21.4 | TEMP BRIDGE/PLATFORMS | milestone | 0d | 2024-04-15 | 2024-04-15 | 24 | 283d | 0d |  |  |
| 26 | 21.5 | TEMP FENCES | milestone | 0d | 2024-04-15 | 2024-04-15 | 25 | 283d | 0d |  |  |
| 27 | 21.6 | EROSION AND SEDIMENT CONTROL | milestone | 0d | 2024-04-15 | 2024-04-15 | 26 | 283d | 0d |  |  |
| 28 | 21.7 | ENVIRONMENTAL PROTECTION | milestone | 0d | 2024-04-15 | 2024-04-15 | 27 | 283d | 0d |  |  |

| ID | WBS | Task | Type | Duration | Start | Finish | Predecessors | Total slack | Free slack |
| --- | --- | --- | --- | --- | --- | --- | --- | --- | --- |
| 29 | 22 | **ROADWORK** |  | 0d | 2024-04-15 | 2024-04-15 |  | 283d |  |
| 30 | 22.1 | REMOVAL OF STRUCTURES AND OBSTRUCTIONS | milestone | 0d | 2024-04-15 | 2024-04-15 | 28 | 283d | 0d |
| 31 | 22.2 | CLEARING AND GRUBBING | milestone | 0d | 2024-04-15 | 2024-04-15 | 30 | 283d | 0d |
| 32 | 22.3 | EARTHWORK | milestone | 0d | 2024-04-15 | 2024-04-15 | 31 | 283d | 0d |
| 33 | 22.4 | SUBGRADE STABILIZATION | milestone | 0d | 2024-04-15 | 2024-04-15 | 32 | 283d | 0d |
| 34 | 22.5 | BLASTING METHODS | milestone | 0d | 2024-04-15 | 2024-04-15 | 33 | 283d | 0d |
| 35 | 22.6 | WATERING | milestone | 0d | 2024-04-15 | 2024-04-15 | 34 | 283d | 0d |
| 36 | 22.7 | TREATED SUBGRADE | milestone | 0d | 2024-04-15 | 2024-04-15 | 35 | 283d | 0d |
| 37 | 22.8 | GEOSYNTHETIC INSTALLATION | milestone | 0d | 2024-04-15 | 2024-04-15 | 36 | 283d | 0d |
| 38 | 22.9 | DRAINAGE BLANKETS | milestone | 0d | 2024-04-15 | 2024-04-15 | 37 | 283d | 0d |
| 39 | 22.10 | FINISHING ROADBEDS | milestone | 0d | 2024-04-15 | 2024-04-15 | 38 | 283d | 0d |
| 40 | 22.11 | RIPRAP PROTECTION | milestone | 0d | 2024-04-15 | 2024-04-15 | 39 | 283d | 0d |
| 41 | 22.12 | SHOTCRETE SLOPE STABILIZATION | milestone | 0d | 2024-04-15 | 2024-04-15 | 40 | 283d | 0d |
| 42 | 22.13 | ROCK SLOPE STABILIZATION | milestone | 0d | 2024-04-15 | 2024-04-15 | 41 | 283d | 0d |
| 43 | 23 | **DRAINAGE AND SEWERS** |  | 0d | 2024-04-15 | 2024-04-15 |  | 283d |  |
| 44 | 23.1 | TRENCH EXCAVATION, BEDDING AND BACKFILL | milestone | 0d | 2024-04-15 | 2024-04-15 | 42 | 283d | 0d |
| 45 | 23.2 | TUNNELING, BORING AND JACKING | milestone | 0d | 2024-04-15 | 2024-04-15 | 44 | 283d | 0d |
| 46 | 23.3 | PIPE LINING | milestone | 0d | 2024-04-15 | 2024-04-15 | 45 | 283d | 0d |
| 47 | 23.4 | PIPE BURSTING AND SLIP LINING | milestone | 0d | 2024-04-15 | 2024-04-15 | 46 | 283d | 0d |
| 48 | 23.5 | CURE IN PLACE LINING | milestone | 0d | 2024-04-15 | 2024-04-15 | 47 | 283d | 0d |
| 49 | 23.6 | VIDEO PIPE INSPECTION | milestone | 0d | 2024-04-15 | 2024-04-15 | 48 | 283d | 0d |
| 50 | 23.7 | SALVAGING PIPE | milestone | 0d | 2024-04-15 | 2024-04-15 | 49 | 283d | 0d |
| 51 | 23.8 | SUBSURFACE DRAINS | milestone | 0d | 2024-04-15 | 2024-04-15 | 50 | 283d | 0d |
| 52 | 23.9 | WEARING SURFACE DRAINS | milestone | 0d | 2024-04-15 | 2024-04-15 | 51 | 283d | 0d |
| 53 | 23.10 | PREFABRICATED VERTICAL DRAINS | milestone | 0d | 2024-04-15 | 2024-04-15 | 52 | 283d | 0d |
| 54 | 23.11 | COMMERCIAL GRADED CONCRETE | milestone | 0d | 2024-04-15 | 2024-04-15 | 53 | 283d | 0d |
| 55 | 23.12 | CONTROLLED LOW STRENGTH MATERIALS | milestone | 0d | 2024-04-15 | 2024-04-15 | 54 | 283d | 0d |
| 56 | 23.13 | SANITARY, STORM, CULVERT, SIPHON, AND IRRIGATION PIPE | milestone | 0d | 2024-04-15 | 2024-04-15 | 55 | 283d | 0d |
| 57 | 23.14 | TRENCH DRAINS | milestone | 0d | 2024-04-15 | 2024-04-15 | 56 | 283d | 0d |
| 58 | 23.15 | STRUCTURAL PLATE SHAPED STRUCTURES | milestone | 0d | 2024-04-15 | 2024-04-15 | 57 | 283d | 0d |
| 59 | 23.16 | PAVED CULVERT END SLOPES | milestone | 0d | 2024-04-15 | 2024-04-15 | 58 | 283d | 0d |
| 60 | 23.17 | MANHOLES, CATCH BASINS, AND INLETS | milestone | 0d | 2024-04-15 | 2024-04-15 | 59 | 283d | 0d |
| 61 | 23.18 | DRY WELLS | milestone | 0d | 2024-04-15 | 2024-04-15 | 60 | 283d | 0d |
| 62 | 23.19 | DRAINAGE CURBS | milestone | 0d | 2024-04-15 | 2024-04-15 | 61 | 283d | 0d |
| 63 | 23.20 | WORK IN EXISTING SEWERS AND STRUCTURES | milestone | 0d | 2024-04-15 | 2024-04-15 | 62 | 283d | 0d |
| 64 | 23.21 | TRENCH | milestone | 0d | 2024-04-15 | 2024-04-15 | 63 | 285d |  |

| ID | WBS | Task | Type | Duration | Start | Finish | Predecessors | Total slack | Free slack |
| --- | --- | --- | --- | --- | --- | --- | --- | --- | --- |
| 65 | 24 | **BRIDGES** |  | 0d | 2024-04-15 | 2024-04-15 |  | 283d |  |
| 66 | 24.1 | #VALUE! | milestone | 0d | 2024-04-15 | 2024-04-15 | 63 | 283d | 0d |
| 116 | 25 | **BASES** |  | 0d | 2024-04-15 | 2024-04-15 |  | 283d |  |
| 117 | 25.1 | RECONDITIONING EXISTING ROADWAY | milestone | 0d | 2024-04-15 | 2024-04-15 | 66 | 283d | 0d |
| 118 | 25.2 | COLD PLANE PAVEMENT REMOVAL | milestone | 0d | 2024-04-15 | 2024-04-15 | 117 | 283d | 0d |
| 119 | 25.3 | GRINDING CONCRETE PAVEMENT | milestone | 0d | 2024-04-15 | 2024-04-15 | 118 | 283d | 0d |
| 120 | 25.4 | GRID-ROLLED AGGREGATE SUBBASE | milestone | 0d | 2024-04-15 | 2024-04-15 | 119 | 283d | 0d |
| 121 | 25.5 | AGGREGATE BASE SHOULDERS | milestone | 0d | 2024-04-15 | 2024-04-15 | 120 | 283d | 0d |
| 122 | 25.6 | AGGREGATE SUBBASE, BASE, AND SHOULDERS | milestone | 0d | 2024-04-15 | 2024-04-15 | 121 | 283d | 0d |
| 123 | 25.7 | STOCKPILE AGGREGATES | milestone | 0d | 2024-04-15 | 2024-04-15 | 122 | 283d | 0d |
| 124 | 26 | **WEARING SURFACES** |  | 0d | 2024-04-15 | 2024-04-15 |  | 283d |  |
| 125 | 26.1 | EMULSIFIED ASPHALT PRIME COAT AND EMULSIFIED ASPHALT FOG COAT | milestone | 0d | 2024-04-15 | 2024-04-15 | 123 | 283d | 0d |
| 126 | 26.2 | EMULSIFIED ASPHALT SLURRY SEAL SURFACING | milestone | 0d | 2024-04-15 | 2024-04-15 | 125 | 283d | 0d |
| 127 | 26.3 | SINGLE APPLICATION EMULSIFIED ASPHALT SURFACE TREATMENT | milestone | 0d | 2024-04-15 | 2024-04-15 | 126 | 283d | 0d |
| 128 | 26.4 | PRE-COATED AGGREGATE ASPHALT SURFACE TREATMENT | milestone | 0d | 2024-04-15 | 2024-04-15 | 127 | 283d | 0d |
| 129 | 26.5 | MULTIPLE APPLICATION EMULSIFIED ASPHALT SURFACE TREATMENT | milestone | 0d | 2024-04-15 | 2024-04-15 | 128 | 283d | 0d |
| 130 | 26.6 | EMULSIFIED ASPHALT TACK COAT | milestone | 0d | 2024-04-15 | 2024-04-15 | 129 | 283d | 0d |
| 131 | 26.7 | EMULSIFIED ASPHALT CONCRETE PAVEMENT | milestone | 0d | 2024-04-15 | 2024-04-15 | 130 | 283d | 0d |
| 132 | 26.8 | COMMERCIAL ASPHALT CONCRETE PAVEMENT | milestone | 0d | 2024-04-15 | 2024-04-15 | 131 | 283d | 0d |
| 133 | 26.9 | POROUS ASPHALT CONCRETE | milestone | 0d | 2024-04-15 | 2024-04-15 | 132 | 283d | 0d |
| 134 | 26.10 | ASPHALT CONCRETE PAVEMENT | milestone | 0d | 2024-04-15 | 2024-04-15 | 133 | 283d | 0d |
| 135 | 26.11 | ASPHALT CONCRETE PAVEMENT | milestone | 0d | 2024-04-15 | 2024-04-15 | 134 | 283d | 0d |
| 136 | 26.12 | CRACK SEALING FLEXIBLE PAVEMENTS | milestone | 0d | 2024-04-15 | 2024-04-15 | 135 | 283d | 0d |
| 137 | 26.13 | ASPHALT CONCRETE PAVEMENT REPAIR | milestone | 0d | 2024-04-15 | 2024-04-15 | 136 | 283d | 0d |
| 138 | 26.14 | MISCELLANEOUS ASPHALT CONCRETE STRUCTURES | milestone | 0d | 2024-04-15 | 2024-04-15 | 137 | 283d | 0d |
| 139 | 26.15 | PLAIN CONCRETE REPAIR | milestone | 0d | 2024-04-15 | 2024-04-15 | 138 | 283d | 0d |
| 140 | 26.16 | CONTINUOUS REINFORCED CONCRETE PAVEMENT | milestone | 0d | 2024-04-15 | 2024-04-15 | 139 | 283d | 0d |
| 141 | 26.17 | PLAIN CONCRETE PAVEMENT | milestone | 0d | 2024-04-15 | 2024-04-15 | 140 | 283d | 0d |
| 142 | 26.18 | REINFORCED CONCRETE PAVEMENT | milestone | 0d | 2024-04-15 | 2024-04-15 | 141 | 283d | 0d |
| 143 | 26.19 | MISCELLANEOUS PORTLAND CEMENT CONCRETE STRUCTURES | milestone | 0d | 2024-04-15 | 2024-04-15 | 142 | 283d | 0d |
| 144 | 26.20 | UNIT PAVERS | milestone | 0d | 2024-04-15 | 2024-04-15 | 143 | 283d | 0d |

| ID | WBS | Task | Type | Duration | Start | Finish | Predecessors | Total slack | Free slack |
| --- | --- | --- | --- | --- | --- | --- | --- | --- | --- |
| 145 | 27 | **PERMANENT TRAFFIC SAFETY AND GUIDANCE DEVICES** |  | 0d | 2024-04-15 | 2024-04-15 |  | 283d |  |
| 146 | 27.1 | METAL GUARDRAIL | milestone | 0d | 2024-04-15 | 2024-04-15 | 144 | 283d | 0d |
| 147 | 27.2 | CABLE BARRIER | milestone | 0d | 2024-04-15 | 2024-04-15 | 146 | 283d | 0d |
| 148 | 27.3 | ADJUSTING AND REPAIRING GUARDRAIL | milestone | 0d | 2024-04-15 | 2024-04-15 | 147 | 283d | 0d |
| 149 | 27.4 | BULLARDS | milestone | 0d | 2024-04-15 | 2024-04-15 | 148 | 283d | 0d |
| 150 | 27.5 | CONCRETE BARRIER | milestone | 0d | 2024-04-15 | 2024-04-15 | 149 | 283d | 0d |
| 151 | 27.6 | GLARE SHIELDS | milestone | 0d | 2024-04-15 | 2024-04-15 | 150 | 283d | 0d |
| 152 | 27.7 | IMPACT ATTENUATORS | milestone | 0d | 2024-04-15 | 2024-04-15 | 151 | 283d | 0d |
| 153 | 27.8 | DELINEATORS AND MULEPOST MARKER POSTS | milestone | 0d | 2024-04-15 | 2024-04-15 | 152 | 283d | 0d |
| 154 | 27.9 | FACILITY IDENTIFICATION MARKERS | milestone | 0d | 2024-04-15 | 2024-04-15 | 153 | 283d | 0d |
| 155 | 27.10 | COMMON PROVISIONS FOR PAVEMENT MARKINGS | milestone | 0d | 2024-04-15 | 2024-04-15 | 154 | 283d | 0d |
| 156 | 27.11 | PAVEMENT MARKING REMOVAL | milestone | 0d | 2024-04-15 | 2024-04-15 | 155 | 283d | 0d |
| 157 | 27.12 | PAVEMENT MARKINGS | milestone | 0d | 2024-04-15 | 2024-04-15 | 156 | 283d | 0d |
| 158 | 27.13 | SURFACE MOUNTED TUBULAR MARKERS | milestone | 0d | 2024-04-15 | 2024-04-15 | 157 | 283d | 0d |
| 159 | 27.14 | RUMBLE STRIPS | milestone | 0d | 2024-04-15 | 2024-04-15 | 158 | 283d | 0d |
| 160 | 27.15 | LONGITUDINAL PAVEMENT MARKINGS - PAINT | milestone | 0d | 2024-04-15 | 2024-04-15 | 159 | 283d | 0d |
| 161 | 27.16 | LONGITUDINAL PAVEMENT MARKINGS - DURABLE | milestone | 0d | 2024-04-15 | 2024-04-15 | 160 | 283d | 0d |
| 162 | 27.17 | LONGITUDINAL PAVEMENT MARKINGS - HIGH PERFORMANCE | milestone | 0d | 2024-04-15 | 2024-04-15 | 161 | 283d | 0d |
| 163 | 27.18 | TRANSVERSE PAVEMENT MARKINGS - LEGENDS AND BARS | milestone | 0d | 2024-04-15 | 2024-04-15 | 162 | 283d | 0d |
| 164 | 28 | **PERMANENT TRAFFIC CONTROL AND ILLUMINATION SYSTEMS** |  | 0d | 2024-04-15 | 2024-04-15 |  | 283d |  |
| 165 | 28.1 | REMOVAL AND REINSTALLATION OF EXISTING SIGNS | milestone | 0d | 2024-04-15 | 2024-04-15 | 163 | 283d | 0d |
| 166 | 28.2 | WOOD SIGN POSTS | milestone | 0d | 2024-04-15 | 2024-04-15 | 165 | 283d | 0d |
| 167 | 28.3 | SIGN SUPPORT FOOTINGS | milestone | 0d | 2024-04-15 | 2024-04-15 | 166 | 283d | 0d |
| 168 | 28.4 | MAJOR SIGN SUPPORT DRILLED SHAFTS | milestone | 0d | 2024-04-15 | 2024-04-15 | 167 | 283d | 0d |
| 169 | 28.5 | METAL SIGN SUPPORTS | milestone | 0d | 2024-04-15 | 2024-04-15 | 168 | 283d | 0d |
| 179 | 28.6 | SIGNS | milestone | 0d | 2024-04-15 | 2024-04-15 |  | 283d | 0d |
| 180 | 28.7 | SIGN COVERS | milestone | 0d | 2024-04-15 | 2024-04-15 | 179 | 283d | 0d |
| 181 | 28.8 | REMOVAL OF ELECTRICAL SYSTEMS | milestone | 0d | 2024-04-15 | 2024-04-15 | 180 | 283d | 0d |
| 182 | 28.9 | COMMON PROVISIONS FOR ELECTRICAL SYSTEMS | milestone | 0d | 2024-04-15 | 2024-04-15 | 181 | 283d | 0d |
| 183 | 28.10 | METAL ILLUMINATION AND TRAFFIC SIGNAL SUPPORTS | milestone | 0d | 2024-04-15 | 2024-04-15 | 182 | 283d | 0d |
| 184 | 28.11 | SIGNAL SUPPORT DRILLED SHAFTS | milestone | 0d | 2024-04-15 | 2024-04-15 | 183 | 283d | 0d |
| 185 | 28.12 | HIGHWAY ILLUMINATION | milestone | 0d | 2024-04-15 | 2024-04-15 | 184 | 283d | 0d |
| 186 | 28.13 | TRAFFIC SIGNALS | milestone | 0d | 2024-04-15 | 2024-04-15 | 185 | 283d | 0d |

| ID | WBS | Task | Type | Duration | Start | Finish | Predecessors | Total slack | Free slack |
| --- | --- | --- | --- | --- | --- | --- | --- | --- | --- |
| 187 | 29 | **RIGHT OF WAY DEVELOPMENT AND CONTROL** |  | 1d | 2024-04-16 | 2024-04-16 |  | 283d |  |
| 188 | 29.1 | WATER QUALITY SWALES |  | 1d | 2024-04-16 | 2024-04-16 | 186 | 283d | 0d |
| 189 | 29.2 | SEEDING | milestone | 0d | 2024-04-16 | 2024-04-16 | 188 | 283d | 0d |
| 190 | 29.3 | PLANTING | milestone | 0d | 2024-04-16 | 2024-04-16 | 189 | 283d | 0d |
| 191 | 29.4 | FENCES | milestone | 0d | 2024-04-16 | 2024-04-16 | 190 | 283d | 0d |
| 192 | 29.5 | MAILBOX SUPPORTS | milestone | 0d | 2024-04-16 | 2024-04-16 | 191 | 283d | 0d |
| 193 | 29.6 | GRAVEL BEDS AND BLANKETS | milestone | 0d | 2024-04-16 | 2024-04-16 | 192 | 283d | 0d |
| 194 | 29.7 | SITE AMMENITIES | milestone | 0d | 2024-04-16 | 2024-04-16 | 193 | 283d | 0d |
| 195 | 30 | **WATER SUPPLY SYSTEMS** |  | 0d | 2024-04-16 | 2024-04-16 |  | 283d |  |
| 196 | 30.1 | IRRIGATION SYSTEMS | milestone | 0d | 2024-04-16 | 2024-04-16 | 194 | 283d | 0d |
| 197 | 30.2 | POTABLE WATER PIPE AND FITTINGS | milestone | 0d | 2024-04-16 | 2024-04-16 | 196 | 283d | 0d |
| 198 | 30.3 | POTABLE WATER VALVES | milestone | 0d | 2024-04-16 | 2024-04-16 | 197 | 283d | 0d |
| 199 | 30.4 | HYDRANTS AND APPURTENANCES | milestone | 0d | 2024-04-16 | 2024-04-16 | 198 | 283d | 0d |
| 200 | 30.5 | POTABLE WATER SERVICE CONNECTIONS, 2 INCH AND SMALLER | milestone | 0d | 2024-04-16 | 2024-04-16 | 199 | 283d | 0d |
| 201 | 31 | **CATHODIC PROTECTION SYSTEMS** |  | 0d | 2024-04-16 | 2024-04-16 |  | 283d |  |
| 202 | 31.1 | LOCATE METAL | milestone | 0d | 2024-04-16 | 2024-04-16 | 200 | 283d | 0d |
| 203 | 31.2 | REPAIR DAMAGED REINFORCING BARS | milestone | 0d | 2024-04-16 | 2024-04-16 | 202 | 283d | 0d |
| 204 | 31.3 | LOCATE AND REPAIR CONCRETE | milestone | 0d | 2024-04-16 | 2024-04-16 | 203 | 283d | 0d |
| 205 | 31.4 | CHECK AND ESTABLISH CONTINUITY | milestone | 0d | 2024-04-16 | 2024-04-16 | 204 | 283d | 0d |
| 206 | 31.5 | PREPARE AND INSTALL ANODES | milestone | 0d | 2024-04-16 | 2024-04-16 | 205 | 283d | 0d |
| 207 | 32 | **PROJECT CONTINGENCY DAYS** |  | 1d | 2024-04-17 | 2024-04-17 |  | 283d |  |
| 208 | 32.1 | WEATHER |  | 1d | 2024-04-17 | 2024-04-17 | 206 | 283d | 0d |
| 209 | 32.2 | LOCAL TIME RESTRICTIONS, MAINTANANCE START, OTHER | milestone | 0d | 2024-04-17 | 2024-04-17 | 208 | 283d |  |
